# Robotics in Scansorial Enviroments

Schedule from MS Project, 2003-08-01 to 2008-07-31.
University of Michigan

## Calendars

- Standard: Mon-Fri 08:00-12:00, 13:00-17:00; Sat-Sun off.

## Resources

| Resource | Group | Unit | Cost per use |
| --- | --- | --- | --- |
| BDI(EE1) | BDI |  |  |
| BDI(ME1) | BDI |  |  |
| BDI(Drafting) | BDI |  |  |
| UMPE-(Karen) | UM |  |  |
| BDI(ME2) | BDI |  |  |
| UMGS-3(Pei-Chun) | UM |  |  |
| Rizzi | CMU |  |  |
| CMUVisionStud | CMU |  |  |
| Koditschek | UM |  |  |
| UCBGS-1(Shai) | UCB |  |  |
| UCBGS-2 | UCB |  |  |
| Fearing | UCB |  |  |
| Full | UCB |  |  |
| 1 week travel | travel | travel | 2000 |
| UCBPD(Goldman) | UCB |  |  |
| Cutkosky | SU |  |  |
| SUGS-1(Jonathan) | SU |  |  |
| SUGS-2 (Daniel) | SU |  |  |
| SUGS-3 | SU |  |  |
| SUGS-4 | SU |  |  |
| SUGS-5 | SU |  |  |
| SUGS-6 | SU |  |  |
| SUPD-A | SU |  |  |
| SUPD-B | SU |  |  |
| BDI(Tech) | BDI |  |  |
| BDI(EE2) | BDI |  |  |
| BDI(Buehler) | BDI |  |  |
| Singh | CMU |  |  |
| UMPD(Hal) | UM |  |  |
| autumn | L&C |  |  |
| Mason | CMU |  |  |
| Buehler | BDI |  |  |
| CMU-Uluc | CMU |  |  |
| CMU-Clark | CMU |  |  |
| CMU-Sarjoun | CMU |  |  |

## Schedule

| ID | WBS | Task | Type | Duration | Start | Finish | Total slack | Free slack | Constraint |
| --- | --- | --- | --- | --- | --- | --- | --- | --- | --- |
| 1 | 1 | **I. Administration** |  | 1305d | 2003-08-01 | 2008-07-31 | 0d |  |  |
| 2 | 1.1 | Award | milestone | 0mo | 2003-08-01 | 2003-08-01 | 777d | 0d | start no earlier than 2003-08-01 |
| 3 | 1.2 | **Monthly Summary Report** |  | 1287d | 2003-08-27 | 2008-07-31 | 0d |  |  |
| 4 | 1.2.1 | Monthly Summary Report 1 |  | 2d | 2003-08-27 | 2003-08-28 | 1285d |  | start no earlier than 2003-08-27 |
| 5 | 1.2.2 | Monthly Summary Report 2 |  | 2d | 2003-09-24 | 2003-09-25 | 1265d |  | start no earlier than 2003-09-24 |
| 6 | 1.2.3 | Monthly Summary Report 3 |  | 2d | 2003-10-29 | 2003-10-30 | 1240d |  | start no earlier than 2003-10-29 |
| 7 | 1.2.4 | Monthly Summary Report 4 |  | 2d | 2003-11-26 | 2003-11-27 | 1220d |  | start no earlier than 2003-11-26 |
| 8 | 1.2.5 | Monthly Summary Report 5 |  | 2d | 2003-12-31 | 2004-01-01 | 1195d |  | start no earlier than 2003-12-31 |
| 9 | 1.2.6 | Monthly Summary Report 6 |  | 2d | 2004-01-28 | 2004-01-29 | 1175d |  | start no earlier than 2004-01-28 |
| 10 | 1.2.7 | Monthly Summary Report 7 |  | 2d | 2004-02-25 | 2004-02-26 | 1155d |  | start no earlier than 2004-02-25 |
| 11 | 1.2.8 | Monthly Summary Report 8 |  | 2d | 2004-03-31 | 2004-04-01 | 1130d |  | start no earlier than 2004-03-31 |
| 12 | 1.2.9 | Monthly Summary Report 9 |  | 2d | 2004-04-28 | 2004-04-29 | 1110d |  | start no earlier than 2004-04-28 |
| 13 | 1.2.10 | Monthly Summary Report 10 |  | 2d | 2004-05-26 | 2004-05-27 | 1090d |  | start no earlier than 2004-05-26 |
| 14 | 1.2.11 | Monthly Summary Report 11 |  | 2d | 2004-06-30 | 2004-07-01 | 1065d |  | start no earlier than 2004-06-30 |
| 15 | 1.2.12 | Monthly Summary Report 12 |  | 2d | 2004-07-28 | 2004-07-29 | 1045d |  | start no earlier than 2004-07-28 |
| 16 | 1.2.13 | Monthly Summary Report 13 |  | 2d | 2004-08-25 | 2004-08-26 | 1025d |  | start no earlier than 2004-08-25 |
| 17 | 1.2.14 | Monthly Summary Report 14 |  | 2d | 2004-09-29 | 2004-09-30 | 1000d |  | start no earlier than 2004-09-29 |
| 18 | 1.2.15 | Monthly Summary Report 15 |  | 2d | 2004-10-27 | 2004-10-28 | 980d |  | start no earlier than 2004-10-27 |
| 19 | 1.2.16 | Monthly Summary Report 16 |  | 2d | 2004-11-24 | 2004-11-25 | 960d |  | start no earlier than 2004-11-24 |
| 20 | 1.2.17 | Monthly Summary Report 17 |  | 2d | 2004-12-29 | 2004-12-30 | 935d |  | start no earlier than 2004-12-29 |
| 21 | 1.2.18 | Monthly Summary Report 18 |  | 2d | 2005-01-26 | 2005-01-27 | 915d |  | start no earlier than 2005-01-26 |
| 22 | 1.2.19 | Monthly Summary Report 19 |  | 2d | 2005-02-23 | 2005-02-24 | 895d |  | start no earlier than 2005-02-23 |
| 23 | 1.2.20 | Monthly Summary Report 20 |  | 2d | 2005-03-30 | 2005-03-31 | 870d |  | start no earlier than 2005-03-30 |
| 24 | 1.2.21 | Monthly Summary Report 21 |  | 2d | 2005-04-27 | 2005-04-28 | 850d |  | start no earlier than 2005-04-27 |
| 25 | 1.2.22 | Monthly Summary Report 22 |  | 2d | 2005-05-25 | 2005-05-26 | 830d |  | start no earlier than 2005-05-25 |
| 26 | 1.2.23 | Monthly Summary Report 23 |  | 2d | 2005-06-29 | 2005-06-30 | 805d |  | start no earlier than 2005-06-29 |
| 27 | 1.2.24 | Monthly Summary Report 24 |  | 2d | 2005-07-27 | 2005-07-28 | 785d |  | start no earlier than 2005-07-27 |
| 28 | 1.2.25 | Monthly Summary Report 25 |  | 2d | 2005-08-31 | 2005-09-01 | 760d |  | start no earlier than 2005-08-31 |
| 29 | 1.2.26 | Monthly Summary Report 26 |  | 2d | 2005-09-28 | 2005-09-29 | 740d |  | start no earlier than 2005-09-28 |
| 30 | 1.2.27 | Monthly Summary Report 27 |  | 2d | 2005-10-26 | 2005-10-27 | 720d |  | start no earlier than 2005-10-26 |
| 31 | 1.2.28 | Monthly Summary Report 28 |  | 2d | 2005-11-30 | 2005-12-01 | 695d |  | start no earlier than 2005-11-30 |
| 32 | 1.2.29 | Monthly Summary Report 29 |  | 2d | 2005-12-28 | 2005-12-29 | 675d |  | start no earlier than 2005-12-28 |
| 33 | 1.2.30 | Monthly Summary Report 30 |  | 2d | 2006-01-25 | 2006-01-26 | 655d |  | start no earlier than 2006-01-25 |
| 34 | 1.2.31 | Monthly Summary Report 31 |  | 2d | 2006-02-22 | 2006-02-23 | 635d |  | start no earlier than 2006-02-22 |
| 35 | 1.2.32 | Monthly Summary Report 32 |  | 2d | 2006-03-29 | 2006-03-30 | 610d |  | start no earlier than 2006-03-29 |
| 36 | 1.2.33 | Monthly Summary Report 33 |  | 2d | 2006-04-26 | 2006-04-27 | 590d |  | start no earlier than 2006-04-26 |
| 37 | 1.2.34 | Monthly Summary Report 34 |  | 2d | 2006-05-31 | 2006-06-01 | 565d |  | start no earlier than 2006-05-31 |
| 38 | 1.2.35 | Monthly Summary Report 35 |  | 2d | 2006-06-28 | 2006-06-29 | 545d |  | start no earlier than 2006-06-28 |
| 39 | 1.2.36 | Monthly Summary Report 36 |  | 2d | 2006-07-26 | 2006-07-27 | 525d |  | start no earlier than 2006-07-26 |
| 40 | 1.2.37 | Monthly Summary Report 37 |  | 2d | 2006-08-30 | 2006-08-31 | 500d |  | start no earlier than 2006-08-30 |
| 41 | 1.2.38 | Monthly Summary Report 38 |  | 2d | 2006-09-27 | 2006-09-28 | 480d |  | start no earlier than 2006-09-27 |
| 42 | 1.2.39 | Monthly Summary Report 39 |  | 2d | 2006-10-25 | 2006-10-26 | 460d |  | start no earlier than 2006-10-25 |
| 43 | 1.2.40 | Monthly Summary Report 40 |  | 2d | 2006-11-29 | 2006-11-30 | 435d |  | start no earlier than 2006-11-29 |
| 44 | 1.2.41 | Monthly Summary Report 41 |  | 2d | 2006-12-27 | 2006-12-28 | 415d |  | start no earlier than 2006-12-27 |
| 45 | 1.2.42 | Monthly Summary Report 42 |  | 2d | 2007-01-31 | 2007-02-01 | 390d |  | start no earlier than 2007-01-31 |
| 46 | 1.2.43 | Monthly Summary Report 43 |  | 2d | 2007-02-28 | 2007-03-01 | 370d |  | start no earlier than 2007-02-28 |
| 47 | 1.2.44 | Monthly Summary Report 44 |  | 2d | 2007-03-28 | 2007-03-29 | 350d |  | start no earlier than 2007-03-28 |
| 48 | 1.2.45 | Monthly Summary Report 45 |  | 2d | 2007-04-25 | 2007-04-26 | 330d |  | start no earlier than 2007-04-25 |
| 49 | 1.2.46 | Monthly Summary Report 46 |  | 2d | 2007-05-30 | 2007-05-31 | 305d |  | start no earlier than 2007-05-30 |
| 50 | 1.2.47 | Monthly Summary Report 47 |  | 2d | 2007-06-27 | 2007-06-28 | 285d |  | start no earlier than 2007-06-27 |
| 51 | 1.2.48 | Monthly Summary Report 48 |  | 2d | 2007-07-25 | 2007-07-26 | 265d |  | start no earlier than 2007-07-25 |
| 52 | 1.2.49 | Monthly Summary Report 49 |  | 2d | 2007-08-29 | 2007-08-30 | 240d |  | start no earlier than 2007-08-29 |
| 53 | 1.2.50 | Monthly Summary Report 50 |  | 2d | 2007-09-26 | 2007-09-27 | 220d |  | start no earlier than 2007-09-26 |
| 54 | 1.2.51 | Monthly Summary Report 51 |  | 2d | 2007-10-31 | 2007-11-01 | 195d |  | start no earlier than 2007-10-31 |
| 55 | 1.2.52 | Monthly Summary Report 52 |  | 2d | 2007-11-28 | 2007-11-29 | 175d |  | start no earlier than 2007-11-28 |
| 56 | 1.2.53 | Monthly Summary Report 53 |  | 2d | 2007-12-26 | 2007-12-27 | 155d |  | start no earlier than 2007-12-26 |
| 57 | 1.2.54 | Monthly Summary Report 54 |  | 2d | 2008-01-30 | 2008-01-31 | 130d |  | start no earlier than 2008-01-30 |
| 58 | 1.2.55 | Monthly Summary Report 55 |  | 2d | 2008-02-27 | 2008-02-28 | 110d |  | start no earlier than 2008-02-27 |
| 59 | 1.2.56 | Monthly Summary Report 56 |  | 2d | 2008-03-26 | 2008-03-27 | 90d |  | start no earlier than 2008-03-26 |
| 60 | 1.2.57 | Monthly Summary Report 57 |  | 2d | 2008-04-30 | 2008-05-01 | 65d |  | start no earlier than 2008-04-30 |
| 61 | 1.2.58 | Monthly Summary Report 58 |  | 2d | 2008-05-28 | 2008-05-29 | 45d |  | start no earlier than 2008-05-28 |
| 62 | 1.2.59 | Monthly Summary Report 59 |  | 2d | 2008-06-25 | 2008-06-26 | 25d |  | start no earlier than 2008-06-25 |
| 63 | 1.2.60 | Monthly Summary Report 60 |  | 2d | 2008-07-30 | 2008-07-31 | 0d |  | start no earlier than 2008-07-30 |

| ID | WBS | Task | Duration | Start | Finish | Total slack | Constraint |
| --- | --- | --- | --- | --- | --- | --- | --- |
| 64 | 1.3 | **Sponsor Quarterly Reporting** | 1179d | 2003-12-01 | 2008-06-05 | 40d |  |
| 65 | 1.3.1 | Sponsor Reporting 1 | 1w | 2003-12-01 | 2003-12-05 | 1214d | start no earlier than 2003-11-30 |
| 66 | 1.3.2 | Sponsor Reporting 2 | 1w | 2004-03-01 | 2004-03-05 | 1149d | start no earlier than 2004-02-29 |
| 67 | 1.3.3 | Sponsor Reporting 3 | 1w | 2004-05-31 | 2004-06-04 | 1084d | start no earlier than 2004-05-30 |
| 68 | 1.3.4 | Sponsor Reporting 4 | 1w | 2004-08-30 | 2004-09-03 | 1019d | start no earlier than 2004-08-30 |
| 69 | 1.3.5 | Sponsor Reporting 5 | 1w | 2004-11-30 | 2004-12-06 | 953d | start no earlier than 2004-11-30 |
| 70 | 1.3.6 | Sponsor Reporting 6 | 1w | 2005-02-28 | 2005-03-04 | 889d | start no earlier than 2005-02-28 |
| 71 | 1.3.7 | Sponsor Reporting 7 | 1w | 2005-05-30 | 2005-06-03 | 824d | start no earlier than 2005-05-30 |
| 72 | 1.3.8 | Sponsor Reporting 8 | 1w | 2005-08-30 | 2005-09-05 | 758d | start no earlier than 2005-08-30 |
| 73 | 1.3.9 | Sponsor Reporting 9 | 1w | 2005-11-30 | 2005-12-06 | 692d | start no earlier than 2005-11-30 |
| 74 | 1.3.10 | Sponsor Reporting 10 | 1w | 2006-02-28 | 2006-03-06 | 628d | start no earlier than 2006-02-28 |
| 75 | 1.3.11 | Sponsor Reporting 11 | 1w | 2006-05-30 | 2006-06-05 | 563d | start no earlier than 2006-05-30 |
| 76 | 1.3.12 | Sponsor Reporting 12 | 1w | 2006-08-30 | 2006-09-05 | 497d | start no earlier than 2006-08-30 |
| 77 | 1.3.13 | Sponsor Reporting 13 | 1w | 2006-11-30 | 2006-12-06 | 431d | start no earlier than 2006-11-30 |
| 78 | 1.3.14 | Sponsor Reporting 14 | 1w | 2007-02-28 | 2007-03-06 | 367d | start no earlier than 2007-02-28 |
| 79 | 1.3.15 | Sponsor Reporting 15 | 1w | 2007-05-30 | 2007-06-05 | 302d | start no earlier than 2007-05-30 |
| 80 | 1.3.16 | Sponsor Reporting 16 | 1w | 2007-08-30 | 2007-09-05 | 236d | start no earlier than 2007-08-30 |
| 81 | 1.3.17 | Sponsor Reporting 17 | 1w | 2007-11-30 | 2007-12-06 | 170d | start no earlier than 2007-11-30 |
| 82 | 1.3.18 | Sponsor Reporting 18 | 1w | 2008-02-29 | 2008-03-06 | 105d | start no earlier than 2008-02-29 |
| 83 | 1.3.19 | Sponsor Reporting 19 | 1w | 2008-05-30 | 2008-06-05 | 40d | start no earlier than 2008-05-30 |
| 84 | 1.4 | **Sponsor PI Meetings** | 1050d | 2003-08-28 | 2007-09-05 | 236d |  |
| 85 | 1.4.1 | Sponsor PI Meetings 1 | 1w | 2003-08-28 | 2003-09-03 | 1281d | start no earlier than 2003-08-28 |
| 86 | 1.4.2 | Sponsor PI Meetings 2 | 1w | 2004-08-26 | 2004-09-01 | 1021d | start no earlier than 2004-08-26 |
| 87 | 1.4.3 | Sponsor PI Meetings 3 | 1w | 2005-08-25 | 2005-08-31 | 761d | start no earlier than 2005-08-25 |
| 88 | 1.4.4 | Sponsor PI Meetings 4 | 1w | 2006-08-31 | 2006-09-06 | 496d | start no earlier than 2006-08-31 |
| 89 | 1.4.5 | Sponsor PI Meetings 5 | 1w | 2007-08-30 | 2007-09-05 | 236d | start no earlier than 2007-08-30 |

| ID | WBS | Task | Duration | Start | Finish | Total slack | Constraint |
| --- | --- | --- | --- | --- | --- | --- | --- |
| 90 | 1.5 | **Teaming Exchange Visits** | 1220d | 2003-10-20 | 2008-06-20 | 29d |  |
| 91 | 1.5.1 | Teaming Exchange Visits 1 | 1w | 2003-10-20 | 2003-10-24 | 1244d | start no earlier than 2003-10-20 |
| 92 | 1.5.2 | Teaming Exchange Visits 2 | 1w | 2003-12-15 | 2003-12-19 | 1204d | start no earlier than 2003-12-15 |
| 93 | 1.5.3 | Teaming Exchange Visits 3 | 1w | 2004-02-16 | 2004-02-20 | 1159d | start no earlier than 2004-02-16 |
| 94 | 1.5.4 | Teaming Exchange Visits 4 | 1w | 2004-04-19 | 2004-04-23 | 1114d | start no earlier than 2004-04-19 |
| 95 | 1.5.5 | Teaming Exchange Visits 5 | 1w | 2004-06-21 | 2004-06-25 | 1069d | start no earlier than 2004-06-21 |
| 96 | 1.5.6 | Teaming Exchange Visits 6 | 1w | 2004-08-16 | 2004-08-20 | 1029d | start no earlier than 2004-08-16 |
| 97 | 1.5.7 | Teaming Exchange Visits 7 | 1w | 2004-10-18 | 2004-10-22 | 984d | start no earlier than 2004-10-18 |
| 98 | 1.5.8 | Teaming Exchange Visits 8 | 1w | 2004-12-20 | 2004-12-24 | 939d | start no earlier than 2004-12-20 |
| 99 | 1.5.9 | Teaming Exchange Visits 9 | 1w | 2005-02-21 | 2005-02-25 | 894d | start no earlier than 2005-02-21 |
| 100 | 1.5.10 | Teaming Exchange Visits 10 | 1w | 2005-04-18 | 2005-04-22 | 854d | start no earlier than 2005-04-18 |
| 101 | 1.5.11 | Teaming Exchange Visits 11 | 1w | 2005-06-20 | 2005-06-24 | 809d | start no earlier than 2005-06-20 |
| 102 | 1.5.12 | Teaming Exchange Visits 12 | 1w | 2005-08-15 | 2005-08-19 | 769d | start no earlier than 2005-08-15 |
| 103 | 1.5.13 | Teaming Exchange Visits 13 | 1w | 2005-10-17 | 2005-10-21 | 724d | start no earlier than 2005-10-17 |
| 104 | 1.5.14 | Teaming Exchange Visits 14 | 1w | 2005-12-19 | 2005-12-23 | 679d | start no earlier than 2005-12-19 |
| 105 | 1.5.15 | Teaming Exchange Visits 15 | 1w | 2006-02-20 | 2006-02-24 | 634d | start no earlier than 2006-02-20 |
| 106 | 1.5.16 | Teaming Exchange Visits 16 | 1w | 2006-04-17 | 2006-04-21 | 594d | start no earlier than 2006-04-17 |
| 107 | 1.5.17 | Teaming Exchange Visits 17 | 1w | 2006-06-19 | 2006-06-23 | 549d | start no earlier than 2006-06-19 |
| 108 | 1.5.18 | Teaming Exchange Visits 18 | 1w | 2006-08-21 | 2006-08-25 | 504d | start no earlier than 2006-08-21 |
| 109 | 1.5.19 | Teaming Exchange Visits 19 | 1w | 2006-10-16 | 2006-10-20 | 464d | start no earlier than 2006-10-16 |
| 110 | 1.5.20 | Teaming Exchange Visits 20 | 1w | 2006-12-18 | 2006-12-22 | 419d | start no earlier than 2006-12-18 |
| 111 | 1.5.21 | Teaming Exchange Visits 21 | 1w | 2007-02-19 | 2007-02-23 | 374d | start no earlier than 2007-02-19 |
| 112 | 1.5.22 | Teaming Exchange Visits 22 | 1w | 2007-04-16 | 2007-04-20 | 334d | start no earlier than 2007-04-16 |
| 113 | 1.5.23 | Teaming Exchange Visits 23 | 1w | 2007-06-18 | 2007-06-22 | 289d | start no earlier than 2007-06-18 |
| 114 | 1.5.24 | Teaming Exchange Visits 24 | 1w | 2007-08-20 | 2007-08-24 | 244d | start no earlier than 2007-08-20 |
| 115 | 1.5.25 | Teaming Exchange Visits 25 | 1w | 2007-10-15 | 2007-10-19 | 204d | start no earlier than 2007-10-15 |
| 116 | 1.5.26 | Teaming Exchange Visits 26 | 1w | 2007-12-17 | 2007-12-21 | 159d | start no earlier than 2007-12-17 |
| 117 | 1.5.27 | Teaming Exchange Visits 27 | 1w | 2008-02-18 | 2008-02-22 | 114d | start no earlier than 2008-02-18 |
| 118 | 1.5.28 | Teaming Exchange Visits 28 | 1w | 2008-04-21 | 2008-04-25 | 69d | start no earlier than 2008-04-21 |
| 119 | 1.5.29 | Teaming Exchange Visits 29 | 1w | 2008-06-16 | 2008-06-20 | 29d | start no earlier than 2008-06-16 |

| ID | WBS | Task | Type | Duration | Start | Finish | Predecessors | Total slack | Free slack | Resources | Work |
| --- | --- | --- | --- | --- | --- | --- | --- | --- | --- | --- | --- |
| 120 | 2 | **II. Platform Design and Fabrication** |  | 1056d? | 2003-08-01 | 2007-08-19 |  | 249d |  |  | 36238.4h |
| 121 | 2.1 | **Platform Body and Limbs** |  | 274d | 2003-08-01 | 2004-08-18 |  | 412d |  |  | 9803.2h |
| 122 | 2.1.1 | **Body/Frame** |  | 253d | 2003-08-01 | 2004-07-20 |  | 419.33d |  |  | 4488h |
| 123 | 2.1.1.1 | Develop candidate body designs |  | 2mo | 2003-08-01 | 2003-10-01 |  | 419.33d | 0d | Buehler; Cutkosky | 704h |
| 124 | 2.1.1.2 | Determine design evaluation criteria |  | 1mo | 2003-09-02 | 2003-10-01 | 123FF | 419.33d | 0d | Buehler; Cutkosky | 352h |
| 125 | 2.1.1.3 | Design spec for "public interfaces" of body | milestone | 0mo | 2003-10-01 | 2003-10-01 | 124, 221 | 419.33d | 0d |  |  |
| 126 | 2.1.1.4 | Evaluate body/frame designs |  | 1mo | 2003-10-02 | 2003-10-31 | 123, 222FF, 125 | 1239d |  | Buehler; Cutkosky | 352h |
| 127 | 2.1.1.5 | Design and build prototype power electronics |  | 0.67mo | 2003-10-02 | 2003-10-22 | 125, 243 | 419.33d | 0d | Buehler; Cutkosky; Rizzi | 352h |
| 128 | 2.1.1.6 | Identify and document body prototype designs |  | 1mo | 2003-10-22 | 2003-11-21 | 127 | 916.33d | 0d | Buehler; Cutkosky | 352h |
| 129 | 2.1.1.7 | Plan for body v0.1 development, and merging of designs | milestone | 0mo | 2003-11-21 | 2003-11-21 | 128 | 916.33d | 0d |  |  |
| 130 | 2.1.1.8 | Build powered body mockups for evaluation and leg/feet integration testing |  | 2mo | 2003-11-21 | 2004-01-22 | 129 | 1048.33d | 0d | Buehler | 352h |
| 131 | 2.1.1.9 | Body Prototypes ready for exchange and evaluation | milestone | 0mo | 2004-01-22 | 2004-01-22 | 130 | 1048.33d | 11d |  |  |
| 132 | 2.1.1.10 | Evaluate body prototypes and refine designs |  | 1.5mo | 2004-02-06 | 2004-03-24 | 131, 133FF | 1037.33d | 29.33d | Buehler; Cutkosky | 528h |
| 133 | 2.1.1.11 | Fabricate Body Prototypes (2) |  | 4mo | 2003-11-21 | 2004-03-24 | 129 | 916.33d | 0d | Buehler | 704h |
| 134 | 2.1.1.12 | RiSE Body v0.1, 3 copies | milestone | 0mo | 2004-03-24 | 2004-03-24 | 133 | 916.33d | 0d |  |  |
| 135 | 2.1.1.13 | Test and Redesign Body |  | 1mo | 2004-05-05 | 2004-06-03 | 232, 132 | 1008d | 0d | Buehler; Cutkosky | 352h |
| 136 | 2.1.1.14 | Fabricate 3 bodies |  | 1.5mo | 2004-06-04 | 2004-07-20 | 135 | 1008d | 0d | Buehler | 264h |
| 137 | 2.1.1.15 | update body hardware design doc |  | 1mo | 2004-06-21 | 2004-07-20 | 136FF | 1052d |  | Buehler | 176h |
| 138 | 2.1.1.16 | Body v1.0 (3 copies) | milestone | 0mo | 2004-07-20 | 2004-07-20 | 136 | 1008d | 11d |  |  |
| 139 | 2.1.2 | **Limb development** |  | 274d | 2003-08-01 | 2004-08-18 |  | 412d |  |  | 5315.2h |
| 140 | 2.1.2.1 | Develop candidate leg designs |  | 2mo | 2003-08-01 | 2003-10-01 |  | 412d | 0d | Buehler; Cutkosky | 704h |
| 141 | 2.1.2.2 | Determine design evaluation criteria |  | 0.5mo | 2003-09-17 | 2003-10-01 | 140FF | 412d | 0d | Buehler; Cutkosky; Koditschek; Rizzi; Full; autumn; Fearing | 616h |
| 142 | 2.1.2.3 | Design spec for limb | milestone | 0mo | 2003-10-01 | 2003-10-01 | 141, 221 | 412d | 0d |  |  |
| 143 | 2.1.2.4 | Evaluate limb designs |  | 0.5mo | 2003-10-02 | 2003-10-16 | 142 | 412d | 0d | Buehler; Cutkosky | 176h |
| 144 | 2.1.2.5 | Initial prototype limb identified | milestone | 0mo | 2003-10-16 | 2003-10-16 | 143 | 412d | 0d |  |  |
| 145 | 2.1.2.6 | Document design for initial limb prototypes |  | 1mo | 2003-10-17 | 2003-11-17 | 144 | 1228d |  | Buehler; Cutkosky | 352h |
| 146 | 2.1.2.7 | fabricate first prototype limbs |  | 0.5mo | 2003-10-17 | 2003-10-31 | 144 | 412d | 0d | BDI(Buehler) | 88h |
| 147 | 2.1.2.8 | Deliver prototype limb to SU | milestone | 0mo | 2003-10-31 | 2003-10-31 | 146 | 412d | 0d |  |  |
| 148 | 2.1.2.9 | Continue limb design evaluations |  | 1.5mo | 2003-10-31 | 2003-12-16 | 143, 226FF+2w | 921d | 0d | Buehler; Cutkosky | 528h |
| 149 | 2.1.2.10 | Plan for Limb v0.1 development, and merging of designs | milestone | 0mo | 2003-12-16 | 2003-12-16 | 148 | 921d | 0d |  |  |
| 150 | 2.1.2.11 | Fabricate limbs v0.1 for integration with bodies and with feet |  | 1mo | 2003-12-17 | 2004-01-15 | 149 | 921d | 0d | Buehler | 176h |
| 151 | 2.1.2.12 | Limb Prototypes V0.1 ready for integration and testing | milestone | 0mo | 2004-01-15 | 2004-01-15 | 150 | 921d | 0d | BDI(ME1); BDI(Tech); BDI(Drafting); BDI(EE1) [40%] |  |
| 152 | 2.1.2.13 | Testing, Redesign improved limb |  | 2mo | 2004-01-16 | 2004-03-17 | 151, 343FF, 350FF | 921d | 0d | BDI(ME1) [60%]; BDI(Tech) [20%]; BDI(Drafting) [20%]; BDI(EE1) [40%]; Cutkosky | 844.8h |
| 153 | 2.1.2.14 | Improved limb prototype V0.2 | milestone | 0mo | 2004-03-17 | 2004-03-17 | 152 | 921d | 0d | BDI(ME1); BDI(Tech); BDI(Drafting); BDI(EE1) [40%] |  |
| 154 | 2.1.2.15 | Testing & Redesign of limbs |  | 2mo | 2004-02-17 | 2004-04-16 | 153FS-1mo | 1031d | 0d | BDI(ME1) [60%]; BDI(Tech) [20%]; BDI(Drafting) [20%]; BDI(EE1) [40%]; Cutkosky | 844.8h |
| 155 | 2.1.2.16 | Manufacturing, Integration |  | 2mo | 2004-04-19 | 2004-06-17 | 154, 355FF | 1031d | 0d | BDI(ME1) [60%]; BDI(Tech) [20%]; BDI(Drafting) [20%]; BDI(EE1) [40%] | 492.8h |
| 156 | 2.1.2.17 | Limb v1.0 ready for integration and testing | milestone | 0mo | 2004-06-17 | 2004-06-17 | 155 | 1031d | 0d | BDI(ME1); BDI(Tech); BDI(Drafting); BDI(EE1) [40%] |  |
| 157 | 2.1.2.18 | Support for delivered limbs |  | 2mo | 2004-06-18 | 2004-08-18 | 156 | 1031d |  | BDI(ME1) [60%]; BDI(Tech) [20%]; BDI(Drafting) [20%]; BDI(EE1) [40%] | 492.8h |

Notes:
- 121: Responsibility for Body & Limbs design and implementation lies with BDI. Since Stanford will need body/limb "substrates" on which to test out their feet, BDI will have to supply Stanford with updated hardware on a recurring basis. Inevitably, there will be some minor "tinkering" at Stanford with the body/limb pieces. This will also force integration between institutions throughout the project from the earliest possible date.
- 123: There will be intense collaboration on the design philosophy between Stanford & BDI.
- 125: Design review will compare notes betweeen Stanford and BDI body frame designs and ensure that common testing and validation studies can be performed at both labs on the physical prototypes thatthey will ship each other at month 6.
- 127: Best case is that this will be a first cut at an onboard system. A fallback position is to employ the RHex motor driver board.
- 130: Likely will be powered from benchtop power systems, not integrated drive electronics
- 131: Stanford and BDI will ship each other physical prototypes for comparative evaluation and testing. / CMU might want a body also for continuing control hardware work.
- 134: Was 2 copies. Al: probably 3 copies at least by this point
- 140: There will be intense collaboration on the design philosophy between Stanford & BDI.
- 142: This design review will ensure that there is commonality in the testing and measurement axes at BDI and Stanford labs so that, Stanford and BDI will be able to ship physical prototypes to each others labs at month for commonly based testing, comparison and validation.
- 145: There will likely be a few parallel candidate independent leg designs to evaluate still.
- 149: Mark wants to once again send hardware prototypes between the BDI and Stanford labs.
- 155: Initial Experience with slip-failure recovery feedback will help guide redesign of limbs and placement of sensors
- 156: Need notes on capabilities and affordances

| ID | WBS | Task | Type | Duration | Start | Finish | Predecessors | Total slack | Free slack | Constraint | Resources | Work |
| --- | --- | --- | --- | --- | --- | --- | --- | --- | --- | --- | --- | --- |
| 158 | 2.2 | **Platform Feet and Appendages** |  | 1056d? | 2003-08-01 | 2007-08-19 |  | 249d |  |  |  | 26224h |
| 159 | 2.2.1 | **1 cm^2 Dry Adhesive patch** |  | 396d | 2003-08-01 | 2005-02-04 |  | 392d |  |  |  | 8448h |
| 160 | 2.2.1.1 | Finish mathematical /mechanical models of spatulae and setal hairs |  | 9mo | 2003-08-01 | 2004-05-04 |  | 909d | 0d |  | Full | 1584h |
| 161 | 2.2.1.2 | Test setal model by measuring force and motion of diverse setae found in nature |  | 9mo | 2004-05-05 | 2005-02-04 | 160 | 909d |  |  | Full | 1584h |
| 162 | 2.2.1.3 | Adhesive patch design |  | 2mo | 2003-08-01 | 2003-10-01 |  | 392d | 0d |  | UCBGS-1(Shai); UCBGS-2 | 704h |
| 163 | 2.2.1.4 | Prototype adhesive patch sample for mounting tests on foot | milestone | 0mo | 2003-10-01 | 2003-10-01 | 162 | 392d | 0d |  |  |  |
| 164 | 2.2.1.5 | Fabrication of footpatch v0.1 |  | 2mo | 2003-10-02 | 2003-12-02 | 163 | 392d | 0d |  | UCBGS-1(Shai); UCBGS-2 | 704h |
| 165 | 2.2.1.6 | FootpatchV0.1: Samples to Foot designers | milestone | 0mo | 2003-12-02 | 2003-12-02 | 164 | 392d | 0d |  |  |  |
| 166 | 2.2.1.7 | FootpatchV0.1: Samples to autumn lab | milestone | 0mo | 2003-12-02 | 2003-12-02 | 164 | 1217d |  |  |  |  |
| 167 | 2.2.1.8 | Test and Redesign |  | 1mo | 2003-12-03 | 2004-01-01 | 165 | 392d | 0d |  | UCBGS-1(Shai); UCBGS-2 | 352h |
| 168 | 2.2.1.9 | Footpatch v0.1 Fabrication for specified limbs |  | 1mo | 2004-01-02 | 2004-02-02 | 167 | 392d | 0d |  | UCBGS-1(Shai); UCBGS-2 | 352h |
| 169 | 2.2.1.10 | Footpatch v0.1 copies delivered to SU | milestone | 0mo | 2004-02-02 | 2004-02-02 | 168 | 392d | 0d |  |  |  |
| 170 | 2.2.1.11 | Footpatch v1.0 Design |  | 3mo | 2004-02-03 | 2004-05-04 | 169 | 392d | 0d |  | UCBGS-1(Shai); UCBGS-2 | 1056h |
| 171 | 2.2.1.12 | Footpatch v1.0 Fabrication |  | 2mo | 2004-05-05 | 2004-07-05 | 170 | 392d | 0d |  | UCBGS-1(Shai); UCBGS-2 | 704h |
| 172 | 2.2.1.13 | Footpatch v1.0 delivered to SU | milestone | 0mo | 2004-07-05 | 2004-07-05 | 171 | 392d | 0d |  |  |  |
| 173 | 2.2.1.14 | Samples delivered to biologists | milestone | 0mo | 2004-07-05 | 2004-07-05 | 171 | 403d | 0d |  |  |  |
| 174 | 2.2.1.15 | Redesign Footpatch for v1.5 (lamellae structure) |  | 2mo | 2004-07-06 | 2004-09-03 | 173, 183 | 403d | 0d |  | UCBGS-1(Shai); UCBGS-2 | 704h |
| 175 | 2.2.1.16 | Footpatch v1.5 Fabrication |  | 2mo | 2004-09-06 | 2004-11-04 | 174 | 403d | 0d |  | UCBGS-1(Shai); UCBGS-2 | 704h |
| 176 | 2.2.1.17 | Adhesive footpatch v1.5 | milestone | 0mo | 2004-11-04 | 2004-11-04 | 175 | 403d | 11d |  |  |  |
| 177 | 2.2.2 | **Biomechanical analysis** |  | 1056d | 2003-08-01 | 2007-08-19 |  | 249d |  |  |  | 6688h |
| 178 | 2.2.2.1 | Determine what key parameters of setae add to dry adhesion |  | 11mo | 2004-09-01 | 2005-08-04 |  | 538d | 0d | start no earlier than 2004-09-01 | Full | 1936h |
| 179 | 2.2.2.2 | Develop Theory for evolution of setal hairs |  | 11mo | 2005-08-05 | 2006-07-10 | 178 | 538d | 0d |  | Full | 1936h |
| 180 | 2.2.2.3 | Published paper | milestone | 0mo | 2006-07-10 | 2006-07-10 | 179 | 538d |  |  | Full |  |
| 181 | 2.2.2.4 | high-speed video and analysis of toe structures |  | 6mo | 2003-08-01 | 2004-02-02 |  | 260d | 0d |  | Full | 1056h |
| 182 | 2.2.2.5 | Biomechanical analysis of feet |  | 6mo | 2003-12-03 | 2004-06-03 | 181FS-2mo | 260d | 0d |  | Full | 1056h |
| 183 | 2.2.2.6 | Lamellae model | milestone | 0mo | 2004-06-03 | 2004-06-03 | 182 | 260d | 22d |  | Full |  |
| 184 | 2.2.2.7 | Impact of Liquid Contaminants |  | 4mo | 2005-06-03 | 2005-10-04 | 183 | 0d |  | must finish on 2005-10-04 | Full | 704h |
| 185 | 2.2.2.8 | Test and Analysis of robot feet side-by-side with gecko feet |  | 4mo | 2007-04-18 | 2007-08-19 | 184 | 0d |  | must finish on 2007-08-19 |  |  |

Notes:
- 158: Responsibility for Feet and Appendate design and implementation lies with Stanford. Since BDI will need trial "appendages" on which to test out body/limbs, Stanford will have to supply BDI with updated hardware on a recurring basis. Inevitably, there will be some minor "tinkering" at BDI with the feet prototypes. This will also force integration between institutions throughout the project from the earliest possible date.
- 162: M6 V0.1 deliverable / Using recent biological results from Full/Autumn labs, fabricate prototype 1 sq. cm. adhesive array with friction coefficient of > 1.0 with compressive loading for glass surface roughness of less than 0.2 micron.
- 163: Mark is convinced he needs something like a sample as early as possible no matter how primitive
- 166: for comparison with gecko feet
- 169: 1 cm^2 array with target adhesion of 0.1 atm, and friction coeff > 1.0atm for glass surface roughness < 0.2 micron
- 170: M12 v1.0 / Using biological results from Full/Autumn labs on surface roughness effects, fabricate prototype 1 sq. cm. adhesive array with target adhesion of 0.1 atmosphere and friction coefficient > 1.0 for surface roughness of 0.2 microns
- 172: 1 cm^2 array with target adhesion of 0.1 atm and friction coeff > 1.0atm for glass surface roughness of 0.2 micron
- 173: 1 cm^2 array with friction coeff > 0.1atm for glass surface roughness of 0.2 micron
- 174: M18 v1.5 / Using biological results from Full/Autumn labs on lamellae structures, fabricate prototype 1 sq. cm. adhesive array with target adhesion of 0.1 atmosphere for surface roughness of 2 microns.
- 176: 1 cm^2 array with target adhesion of 0.1 atm for glass surface roughness of 2 microns
- 177: Most of this is owned by Stanford

| ID | WBS | Task | Type | Duration | Start | Finish | Predecessors | Total slack | Free slack | Constraint | Resources | Work |
| --- | --- | --- | --- | --- | --- | --- | --- | --- | --- | --- | --- | --- |
| 186 | 2.2.3 | **Clawed Sticky Feet (passive)** |  | 363d? | 2003-08-01 | 2004-12-21 |  | 412d |  |  |  |  |
| 187 | 2.2.3.1 | Develop candidate foot designs |  | 2mo | 2003-08-01 | 2003-10-01 |  | 412d | 0d |  |  |  |
| 188 | 2.2.3.2 | Determine design evaluation criteria |  | 1mo | 2003-09-02 | 2003-10-01 | 187FF | 412d | 0d |  |  |  |
| 189 | 2.2.3.3 | Design spec for "public interfaces" of foot | milestone | 0mo | 2003-10-01 | 2003-10-01 | 188, 220 | 412d | 0d |  |  |  |
| 190 | 2.2.3.4 | Evaluate foot designs |  | 0.5mo | 2003-10-02 | 2003-10-16 | 189 | 412d | 0d |  |  |  |
| 191 | 2.2.3.5 | Initial prototype foot identified | milestone | 0mo | 2003-10-16 | 2003-10-16 | 190 | 412d | 0d |  |  |  |
| 192 | 2.2.3.6 | Document design for initial foot prototypes |  | 1mo | 2003-10-17 | 2003-11-17 | 191 | 1228d |  |  |  |  |
| 193 | 2.2.3.7 | fabricate first prototype foot |  | 0.5mo? | 2003-10-17 | 2003-10-31 | 191 | 412d | 0d |  |  |  |
| 194 | 2.2.3.8 | Deliver prototype foot to BDI | milestone | 0mo | 2003-10-31 | 2003-10-31 | 193 | 412d | 0d |  |  |  |
| 195 | 2.2.3.9 | Continue foot design evaluations |  | 1mo | 2003-11-17 | 2003-12-16 | 194, 226FF+2w | 1174d | 0d |  |  |  |
| 196 | 2.2.3.10 | Plan for Foot v0.1 development, and merging of adhesive patch | milestone | 0mo | 2003-12-16 | 2003-12-16 | 195 | 1174d | 0d |  |  |  |
| 197 | 2.2.3.11 | Fabricate foot Prototypes for integration onto legs |  | 1mo | 2003-12-17 | 2004-01-15 | 196 | 1174d | 0d |  |  |  |
| 198 | 2.2.3.12 | Foot prototypes v0.1 ready for integration and testing | milestone | 0mo | 2004-01-15 | 2004-01-15 | 197 | 1174d | 4.67d |  |  |  |
| 199 | 2.2.3.13 | Adhesive Patch integration |  | 5mo | 2003-10-02 | 2004-03-03 | 163, 169FF, 343FF, 350FF | 392d | 0d |  |  |  |
| 200 | 2.2.3.14 | Passive Sticky Foot v0.2 prototype ready | milestone | 0mo | 2004-03-03 | 2004-03-03 | 199 | 392d | 0d |  |  |  |
| 201 | 2.2.3.15 | Testing, hardening and redesign of passive sticky foot |  | 2mo | 2004-03-04 | 2004-05-04 | 200, 355FF | 392d | 0d |  |  |  |
| 202 | 2.2.3.16 | fabricate foot prototypes v1.0 for integration onto limb |  | 2mo | 2004-05-05 | 2004-07-05 | 201, 355FF | 392d | 0d |  |  |  |
| 203 | 2.2.3.17 | Integrate footpatch v1.0 |  | 1mo | 2004-07-06 | 2004-08-04 | 172, 202 | 392d | 0d |  |  |  |
| 204 | 2.2.3.18 | Passive Sticky foot v 1.0 | milestone | 0mo | 2004-08-04 | 2004-08-04 | 203 | 392d | 0d |  |  |  |
| 205 | 2.2.3.19 | Testing, hardening and redesign of foot v1.5 |  | 2mo | 2004-08-05 | 2004-10-05 | 204 | 392d | 0d |  |  |  |
| 206 | 2.2.3.20 | fabricate foot prototypes v1.5 for integration |  | 1.5mo | 2004-10-06 | 2004-11-19 | 205 | 392d | 0d |  |  |  |
| 207 | 2.2.3.21 | Adhesive Patch v1.5 integration |  | 1mo | 2004-11-22 | 2004-12-21 | 176, 206 | 392d | 0d |  |  |  |
| 208 | 2.2.3.22 | Passive Sticky Foot v1.5 | milestone | 0mo | 2004-12-21 | 2004-12-21 | 207 | 942d |  |  |  |  |
| 209 | 2.2.4 | **Active Adhesive Toes (attach/release)** |  | 550d | 2004-12-22 | 2007-01-30 | 207 | 392d |  |  |  | 11088h |
| 210 | 2.2.4.1 | Determine optimal toe kinematics for engagement and release |  | 4mo | 2004-12-22 | 2005-04-22 | 176 | 392d | 0d |  | UCBGS-1(Shai); UCBGS-2 | 1408h |
| 211 | 2.2.4.2 | Design active toe patch, long-life, self-cleaning |  | 6mo | 2005-04-25 | 2005-10-25 | 210 | 392d | 0d |  | UCBGS-1(Shai); UCBGS-2; SUGS-3; SUPD-A [30%] | 3484.8h |
| 212 | 2.2.4.3 | Fabrication |  | 8mo | 2005-10-26 | 2006-06-28 | 211 | 392d | 0d | start no earlier than 2001-04-02 | UCBGS-1(Shai); UCBGS-2 | 2816h |
| 213 | 2.2.4.4 | Prototype to BDI | milestone | 0mo | 2006-06-28 | 2006-06-28 | 212 | 392d | 0d | start no earlier than 2006-01-08 |  |  |
| 214 | 2.2.4.5 | Test and Redesign |  | 4mo | 2006-06-29 | 2006-10-30 | 213 | 392d | 0d |  | UCBGS-1(Shai); UCBGS-2; SUGS-3; SUPD-A [30%] | 2323.2h |
| 215 | 2.2.4.6 | Fabrication |  | 3mo | 2006-10-31 | 2007-01-30 | 214 | 392d | 0d |  | UCBGS-1(Shai); UCBGS-2 | 1056h |
| 216 | 2.2.4.7 | 1atm adhesion, self-cleaning, longlife | milestone | 0mo | 2007-01-30 | 2007-01-30 | 215 | 392d |  |  |  |  |
| 217 | 2.2.5 | Biomechanical analysis of toes |  | 6mo | 2004-12-22 | 2005-06-23 | 210SS | 810d |  |  |  |  |

Notes:
- 187: Will be testing and developingseveral variant designs: foot A, foot B, etc.
- 196: A menu of feet: foot A, foot B, foot C
- 201: Initial Experience with slip-failure recovery feedback will help guide redesign of foot and sensor placement
- 210: Ron: 2.2.4.1, optimal toe kinematics determined by month 30 (2/06), so start should be 8/05 instead of 2/05
- 211: ronf: line 203.5, v3.0 patch started 8/06 to be ready at 2/07
- 213: 1.0atm adhesion to rough and smooth surfaces / long lifetime and self-cleaning capabilities
- 214: line 204 design of Selfcleaning patch, v 4.0 would start 12/06 to be ready by 8/07 / line 205 v4.0 fabrication would start 2/07 to be ready by 8/07 / line 209, v 4.0 patch 8/07

| ID | WBS | Task | Type | Duration | Start | Finish | Predecessors | Total slack | Free slack | Resources | Work |
| --- | --- | --- | --- | --- | --- | --- | --- | --- | --- | --- | --- |
| 218 | 2.3 | **Platform Integration and Assembly** |  | 308d | 2003-08-01 | 2004-10-05 |  | 412d |  |  | 211.2h |
| 219 | 2.3.1 | identify platform design-space axes and interfaces |  | 1mo | 2003-08-01 | 2003-09-01 |  | 412d | 0d |  |  |
| 220 | 2.3.2 | functional and physical decomposition of limb regarding both body and foot |  | 2mo | 2003-08-01 | 2003-10-01 | 219SS | 412d | 0d |  |  |
| 221 | 2.3.3 | design specifications for "public interfaces" of body, body-limb, limb-foot, foot and power system | milestone | 0mo | 2003-10-01 | 2003-10-01 | 220 | 412d | 0d |  |  |
| 222 | 2.3.4 | Functional Design Review | milestone | 0mo | 2003-10-01 | 2003-10-01 | 221 | 418.78d | 0d |  |  |
| 223 | 2.3.5 | Initial benchtop control system at CMU, SU and BDI | milestone | 0mo | 2003-10-31 | 2003-10-31 | 241, 262, 127 | 412d | 0d |  |  |
| 224 | 2.3.6 | Exchange of single Foot and Limb between BDI and SU | milestone | 0mo | 2003-10-31 | 2003-10-31 | 147, 194, 223 | 412d | 0d |  |  |
| 225 | 2.3.7 | Integration of foot onto limb at BDI and SU |  | 1mo | 2003-11-03 | 2003-12-02 | 224 | 412d | 0d |  |  |
| 226 | 2.3.8 | Prototype Limb with Foot for evaluation and testing | milestone | 0mo | 2003-12-02 | 2003-12-02 | 225 | 412d | 0d |  |  |
| 227 | 2.3.9 | Integration of Foot v0.1 and Limb v0.1 onto Body Prototypes |  | 0.5mo | 2004-01-22 | 2004-02-06 | 151, 198, 130 | 1169.33d | 0d |  |  |
| 228 | 2.3.10 | First platform exchange: upgraded feet and limbs, now on prototype body | milestone | 0mo | 2004-02-06 | 2004-02-06 | 227, 131, 151, 198 | 1169.33d | 0d |  |  |
| 229 | 2.3.11 | Prototype platform controlled by stack v0.1 on benchtop | milestone | 0mo | 2004-02-06 | 2004-02-06 | 228, 265 | 1169.33d |  |  |  |
| 230 | 2.3.12 | Integration of Body v0.1, limb v0.2 and foot v0.2 |  | 1mo | 2004-03-24 | 2004-04-23 | 200, 134, 153 | 916.33d | 7.33d |  |  |
| 231 | 2.3.13 | Electronics and sensor integration |  | 1mo | 2004-03-19 | 2004-04-19 | 250, 269, 267SS+1mo, 293 | 920d | 11d |  |  |
| 232 | 2.3.14 | Second exchange: RiSE platform v0.2 w/ sticky foot v0.2, improved limb | milestone | 0mo | 2004-05-04 | 2004-05-04 | 230, 134, 153, 200, 231, 248, 295 | 909d | 0d |  |  |
| 233 | 2.3.15 | Platform v 1.0 Integration & Testing |  | 1mo | 2004-08-05 | 2004-09-03 | 156, 204, 138, 253 | 997d | 0d | Cutkosky [60%]; Buehler [60%] | 211.2h |
| 234 | 2.3.16 | Third exchange: RiSE v1.0, revised body, Foot v1.0, Limb v1.0, controls v1.0 | milestone | 0mo | 2004-09-03 | 2004-09-03 | 233, 138, 156, 204, 297 | 997d | 0d |  |  |
| 235 | 2.3.17 | Integrate revised mechanicals, electronics, and software |  | 1mo | 2004-09-06 | 2004-10-05 | 234, 138, 273 | 997d | 0d |  |  |
| 236 | 2.3.18 | RiSE v1.0, 3 copies | milestone | 0mo | 2004-10-05 | 2004-10-05 | 235 | 997d |  |  |  |
| 237 | 3 | **III. Sensors and Software** |  | 990d? | 2003-08-01 | 2007-05-17 |  | 315d |  |  | 12584h |
| 238 | 3.1 | **Control Architecture** |  | 396d | 2003-08-01 | 2005-02-04 |  | 412d |  |  | 3168h |
| 239 | 3.1.1 | **design and develop control hardware** |  | 396d | 2003-08-01 | 2005-02-04 |  | 419.33d |  |  | 2816h |
| 240 | 3.1.1.1 | Identify & Design Control Hardware Transition |  | 1.5mo | 2003-08-01 | 2003-09-16 |  | 423d | 0d | Rizzi; Cutkosky; Buehler | 792h |
| 241 | 3.1.1.2 | Specify, Purchase and Deploy Benchtop control hardware |  | 1mo | 2003-09-17 | 2003-10-16 | 240 | 423d | 11d |  |  |
| 242 | 3.1.1.3 | Identify requirements for Control System |  | 2mo | 2003-08-01 | 2003-10-01 |  | 419.33d | 0d |  |  |
| 243 | 3.1.1.4 | Functional Design spec for platform control hardware, incl closed-loop sensing | milestone | 0mo | 2003-10-01 | 2003-10-01 | 240, 242 | 419.33d | 0d |  |  |
| 244 | 3.1.1.5 | Design and fabrication of hip/leg ctl hardware |  | 1.5mo | 2003-10-02 | 2003-11-17 | 243 | 1217d | 0d | Rizzi; Cutkosky; Buehler | 792h |
| 245 | 3.1.1.6 | Document design of hip/leg control module |  | 0.5mo | 2003-11-18 | 2003-12-02 | 244 | 1217d |  |  |  |
| 246 | 3.1.1.7 | Design & fabrication of benchtop-to-robot control bridge |  | 1mo | 2003-10-02 | 2003-10-31 | 243 | 986d | 0d |  |  |
| 247 | 3.1.1.8 | integration, test, redesign of hip/leg control module |  | 1.5mo | 2003-12-03 | 2004-01-16 | 246, 226 | 986d | 0d |  |  |
| 248 | 3.1.1.9 | Hip/leg ctrl modules completed for integration onto M9 platform | milestone | 0mo | 2004-01-16 | 2004-01-16 | 247, 265 | 986d | 77d |  |  |
| 249 | 3.1.1.10 | design and fabrication of components for onboard robot control hardware |  | 1.5mo | 2003-11-03 | 2003-12-17 | 246 | 986d | 55d |  |  |
| 250 | 3.1.1.11 | Prototype control hardware complete for integration onto M9 platform | milestone | 0mo | 2004-03-03 | 2004-03-03 | 249, 267FF | 931d | 0d |  |  |
| 251 | 3.1.1.12 | Document central control system hardware |  | 0.5mo | 2004-03-04 | 2004-03-18 | 250 | 986d | 0d |  |  |
| 252 | 3.1.1.13 | Complete Controls Electronics specification v0.1 | milestone | 0mo | 2004-03-18 | 2004-03-18 | 251, 244 | 986d | 77d |  |  |
| 253 | 3.1.1.14 | integrate, test and redesign central control hardware |  | 2mo | 2004-05-05 | 2004-07-05 | 265, 232 | 909d | 0d | Cutkosky; Rizzi; Buehler | 1056h |
| 254 | 3.1.1.15 | Update Control hardware specification docs |  | 1mo | 2004-07-06 | 2004-08-04 | 253, 252 | 909d | 0d | Rizzi | 176h |
| 255 | 3.1.1.16 | Platform electronics specification v1.0 | milestone | 0mo | 2004-08-04 | 2004-08-04 | 254 | 909d | 0d |  |  |
| 256 | 3.1.1.17 | control hardware support |  | 6mo | 2004-08-05 | 2005-02-04 | 255, 253 | 909d |  |  |  |

Notes:
- 220: assignment of design and implementation responsibility / axes at body and foot / angle of approach at touchdown / angle of departure from limb
- 223: Revised version of RHexLib released to RiSE group (includes revised hardware abstraction layer and improved computational performance) will be delivered to BDI and SU in early October 2003.
- 224: BDI will deliver a copy of the early prototype hip/leg assembly to CMU at the same time it delivers one to SU (enc of October)
- 228: CMU will deploy a working benchtop->RiSE-Bus converter to BDI and SU for use with the M6 prototype.
- 232: M9 prototype, v0.2 / Al wants to call this version 1.0 / AL: We plan to have version 1.0 electronics (main board, CPU modules, hip and leg "remote nodes") fully integrated with the M9 prototype.
- 234: Need notes on capabilites and affordances / Available at M12
- 236: one copy at Stanford / one copy at BDI / one copy shared btwn UM and CMU
- 238: Because of the tight timing, all institutions will need early (benchtop) control hardware and software prototypes from the very earliest moment they begin to drive prototype hardware around. All institutions have agreed to let CMU coordinate the design/purchase decisions with the responsibility for leading (and providng some "user support" for) the implementation.
- 240: design a strategy for supporting early hardware prototypes in parallel with design and development of final control / system for the robot
- 241: purchase hardware (primarily at SU, because they have no RHex stack) to support early testing of mechanical prototypes (depends on above, feeds M3 synchronization) / purchases made by each institution: BDI, SU, UM, CMU
- 242: identify system level requirements and candidate architectures for overall robot control system
- 243: Includes spec for closed-loop control sensors only, not all sensors at this point
- 244: design of hip/leg control node -- 8051 based "remote node" on RiSEbus / (used for M6 prototype) / Specify vendors, model numbers/part numbers and any special configurations / Includes all control channels and proprioceptive sensing devices / Must distinguish sensor components situated on body, limbs, and feet and account for power and data lines to all groups.
- 246: design of bridge between benchtop control stack and RiSEbus system (used for M6 prototype)
- 247: purchase, fab, evaluation and refinement of hardware used for hip/leg control module / AL: This is the M12 version, so there will be 6 copies (plus spares) per robot. How many robots are wen building at M12? Presumably Martin will be buying this stuff and Don will be fabing -- possibly we (CMU) shift some purchasing and construction to CMU if BDI is swamped.
- 249: design and selection of central CPU, power conditioning, off-robot communication, etc. / (used for M9 prototype)
- 252: Includes schematic of signal interconnections: all stage 1 hardware planned to be built by Jan 3. / Purchase two complete sets of control hardware.
- 256: [Kod: probably this task should end here so we can free resources up for behavioral development, noi?]

| ID | WBS | Task | Type | Duration | Start | Finish | Predecessors | Total slack | Free slack | Resources | Work |
| --- | --- | --- | --- | --- | --- | --- | --- | --- | --- | --- | --- |
| 257 | 3.1.2 | **design and develop RiSELib control software** |  | 396d | 2003-08-01 | 2005-02-04 |  | 412d |  |  | 352h |
| 258 | 3.1.2.1 | Identify & Select control system software |  | 2mo | 2003-08-01 | 2003-10-01 |  | 412d | 0d |  |  |
| 259 | 3.1.2.2 | document Control system architecture |  | 0.5mo | 2003-10-02 | 2003-10-16 | 258 | 1250d | 0d |  |  |
| 260 | 3.1.2.3 | Functional Design spec for control system software architecture & Selection of Benchtop | milestone | 0mo | 2003-10-16 | 2003-10-16 | 259, 258 | 1250d |  |  |  |
| 261 | 3.1.2.4 | RHexLib and SprawlOS merger and refinement |  | 1mo | 2003-10-02 | 2003-10-31 | 258 | 412d | 0d |  |  |
| 262 | 3.1.2.5 | Benchtop control for M3 hip/leg prototype, RLB v0.1 | milestone | 0mo | 2003-10-31 | 2003-10-31 | 261, 241 | 412d | 0d |  |  |
| 263 | 3.1.2.6 | Document benchtop control system |  | 0.5mo | 2003-11-03 | 2003-11-17 | 262 | 920d | 0d |  |  |
| 264 | 3.1.2.7 | Develop RiSE software control infrastructure |  | 1.5mo | 2003-11-18 | 2004-01-01 | 263 | 920d | 0d |  |  |
| 265 | 3.1.2.8 | Basic control infrastructure operational - RLB v1.0 | milestone | 0mo | 2004-01-01 | 2004-01-01 | 264 | 920d | 0d |  |  |
| 266 | 3.1.2.9 | Document RiSE control infrastructure |  | 0.5mo | 2004-01-02 | 2004-01-16 | 265 | 1184d |  |  |  |
| 267 | 3.1.2.10 | Develop RiSE mid-level control software |  | 2mo | 2004-01-02 | 2004-03-03 | 265 | 920d | 0d |  |  |
| 268 | 3.1.2.11 | Document mid-level control system |  | 0.5mo | 2004-03-04 | 2004-03-18 | 267 | 920d | 0d |  |  |
| 269 | 3.1.2.12 | RiSE Control System v1.0 | milestone | 0mo | 2004-03-18 | 2004-03-18 | 268 | 920d | 0d |  |  |
| 270 | 3.1.2.13 | test, evaluate and redesign control software |  | 2mo | 2004-05-05 | 2004-07-05 | 253FF, 269 | 909d | 0d | Rizzi | 352h |
| 271 | 3.1.2.14 | Implement and test design changes |  | 1mo | 2004-07-06 | 2004-08-04 | 270 | 909d | 0d |  |  |
| 272 | 3.1.2.15 | update control system software documentation |  | 1mo | 2004-07-06 | 2004-08-04 | 271FF | 909d | 0d |  |  |
| 273 | 3.1.2.16 | Control system software v 1.1 | milestone | 0mo | 2004-08-04 | 2004-08-04 | 271, 272 | 909d | 0d |  |  |
| 274 | 3.1.2.17 | control software support |  | 6mo | 2004-08-05 | 2005-02-04 | 273 | 909d |  |  |  |
| 275 | 3.2 | **Proprioceptive Sensory Suite** |  | 990d | 2003-08-01 | 2007-05-17 |  | 315d |  |  | 6248h |
| 276 | 3.2.1 | **Internal Motion Unit** |  | 341d | 2003-08-01 | 2004-11-19 |  | 931d |  |  | 4840h |
| 277 | 3.2.1.1 | Evaluate RHex IMU Board & Compare to Alternatives |  | 2mo | 2003-08-01 | 2003-10-01 |  | 931d | 0d | UMPD(Hal) | 352h |
| 278 | 3.2.1.2 | Design, Build & Bench Test integrated IMU |  | 3mo | 2003-10-02 | 2004-01-01 | 277 | 931d | 0d | UMPD(Hal) | 528h |
| 279 | 3.2.1.3 | Install IMU, Test & Redesign on Protoytype Platforms |  | 3mo | 2004-01-02 | 2004-04-02 | 278 | 931d | 0d | UMPD(Hal) | 528h |
| 280 | 3.2.1.4 | Distribute IMU to Other sites | milestone | 0mo | 2004-04-02 | 2004-04-02 | 279 | 931d | 0d | UMPD(Hal) |  |
| 281 | 3.2.1.5 | Test and redesign |  | 6mo | 2004-04-05 | 2004-10-05 | 280 | 997d |  | UMPD(Hal) [50%] | 528h |
| 282 | 3.2.1.6 | IMU sensor fusion strategy development |  | 6mo | 2004-01-02 | 2004-07-05 | 278 | 964d | 0d | UMGS-3(Pei-Chun); CMU-Sarjoun [50%] | 1056h |
| 283 | 3.2.1.7 | IMU software implementation |  | 1.5mo | 2004-05-20 | 2004-07-05 | 280, 282FF | 964d | 0d | UMPD(Hal) [50%]; CMU-Sarjoun [50%] | 264h |
| 284 | 3.2.1.8 | IMU algorithm test, eval and refinement |  | 6mo | 2004-05-20 | 2004-11-19 | 283SS | 964d | 0d | UMGS-3(Pei-Chun); CMU-Sarjoun [50%] | 1584h |
| 285 | 3.2.1.9 | Final IMU Algorithms Disseminated & Documented | milestone | 0mo | 2004-11-19 | 2004-11-19 | 284, 281 | 964d |  |  |  |

Notes:
- 257: Shai Revson at Berkeley; Trey Armstrong at Stanford will represent west coast; Hal Komsuoglu will represent UM, ?? will represent BDI; CMU will lead software architecure defintion and specification effort.
- 258: Identify candidate sw control environments, evaluate and select.criteria
- 259: description of the proposed software control system architecture identifying reused components from predecessor projects and new components
- 260: Benchtop test environments must be purchased *now* at all the institutions to allow setup and learning in advance of the mutual testing of platforms components (body, limbs, feet) between BDI & Stanford. [Need appropriate links to the platform lines]
- 261: initial implementation of basic library infrastructure for RiSE project. key components recovered from RHex and Sprawl. / (depends on 1st task, feeds M3 prototype)
- 264: development of low-level software infrastructure -- device abstractions, module management, on-robot communication, etc. -- to support use of hip/leg modules / (depends on above, feeds M6 prototype)
- 267: development of mid-level software infrastructure -- control/coordination modules, off-robot communication, operating mode abstractions, etc. -- to support coordinated control of 6 hip/leg modules. / (depends on above, feeds M9 prototype)
- 270: major evaluation and redesign to provide stable platform for M12 / (feeds M12 prototype)
- 276: Must adapt the RHex suite to the smaller RiSE platform. Principally need to replace large gyro with cheaper/smaller solid state units.
- 284: feed some behavioral task at/near M15

| ID | WBS | Task | Type | Duration | Start | Finish | Predecessors | Total slack | Free slack | Resources | Work |
| --- | --- | --- | --- | --- | --- | --- | --- | --- | --- | --- | --- |
| 286 | 3.2.2 | **Contact, Strain, Grip Sensors** |  | 990d | 2003-08-01 | 2007-05-17 |  | 315d |  |  | 1408h |
| 287 | 3.2.2.1 | Biological sensor design and implementation |  | 45mo | 2003-08-01 | 2007-05-17 |  | 315d |  |  |  |
| 288 | 3.2.2.2 | Identify technology for pressure sensor and acceleration |  | 2mo | 2003-08-01 | 2003-10-01 |  | 434d | 0d |  |  |
| 289 | 3.2.2.3 | Develop early benchtop prototypes |  | 3mo | 2003-08-01 | 2003-10-31 | 288SS | 434d | 0d | UMGS-3(Pei-Chun); SUGS-3 | 1056h |
| 290 | 3.2.2.4 | Benchtop prototype of foot pressure sensor and in-plane acceleration sensor | milestone | 0mo | 2003-10-31 | 2003-10-31 | 289 | 434d | 22d |  |  |
| 291 | 3.2.2.5 | Integrate Prototype sensors onto first limb/foot |  | 2mo | 2003-12-03 | 2004-02-02 | 226, 290 | 412d | 0d | UMGS-3(Pei-Chun) | 352h |
| 292 | 3.2.2.6 | Integrate local processor for connection to RiSE comm system |  | 2mo | 2003-12-03 | 2004-02-02 | 291FF | 412d | 0d |  |  |
| 293 | 3.2.2.7 | Prototype sensors deployed onto limb/foot assembly | milestone | 0mo | 2004-02-02 | 2004-02-02 | 291, 292 | 412d | 0d |  |  |
| 294 | 3.2.2.8 | Test, redesign, upgrade sensor deployment to improve sensitivity |  | 3mo | 2004-02-03 | 2004-05-04 | 293 | 909d | 0d |  |  |
| 295 | 3.2.2.9 | Sensors measure foot acceleration plus passive leg kinematics and/or ground reaction forces | milestone | 0mo | 2004-05-04 | 2004-05-04 | 294 | 909d | 0d |  |  |
| 296 | 3.2.2.10 | Explore strategies for low-res proximity detection |  | 3mo | 2004-05-05 | 2004-08-04 | 295 | 909d | 0d |  |  |
| 297 | 3.2.2.11 | Proximity detection on feet to enhance touchdown prediction and detection | milestone | 0mo | 2004-08-04 | 2004-08-04 | 296 | 909d | 0d |  |  |
| 298 | 3.2.2.12 | Support of Mechanical Sensing Devices |  | 4mo | 2004-08-05 | 2004-12-06 | 297 | 953d |  |  |  |
| 299 | 3.3 | **Exteroceptive Sensory Suite** |  | 528d | 2003-08-01 | 2005-08-09 |  | 777d |  |  | 3168h |
| 300 | 3.3.1 | **Integration of Visual Sensing Devices** |  | 264d | 2003-08-01 | 2004-08-04 |  | 964d |  |  | 3168h |
| 301 | 3.3.1.1 | Familiarization with Sanjiv Singh's Small vision Systme |  | 4mo | 2003-08-01 | 2003-12-02 |  | 964d | 0d | Rizzi | 704h |
| 302 | 3.3.1.2 | Implementation of RiSE Visual Library on Smal Vision System |  | 2mo | 2003-12-03 | 2004-02-02 | 301 | 964d | 0d | Rizzi | 352h |
| 303 | 3.3.1.3 | Working Visual Sensors v0.1 for Initial RiSE platform | milestone | 0mo | 2004-02-02 | 2004-02-02 | 302 | 964d | 0d |  |  |
| 304 | 3.3.1.4 | Evaluate future bandwidth requirements and strategies for distributed sensor processing |  | 6mo | 2004-02-03 | 2004-08-04 | 303 | 1041d |  | Cutkosky; Rizzi | 2112h |
| 305 | 3.3.2 | Design and develop sensor software |  | 6mo | 2005-02-07 | 2005-08-09 | 2SS+18mo | 940d |  |  |  |
| 306 | 3.4 | User Interface |  | 0.05mo? | 2003-08-01 | 2003-08-01 |  | 1467d |  |  |  |
| 307 | 4 | **IV. Kinematic and Dynamic Behaviors** |  | 377.14d? | 2003-08-01 | 2005-01-11 |  | 416.87d |  |  | 16368h |
| 308 | 4.1 | **Simulation and Modeling** |  | 278.67d | 2003-08-01 | 2004-08-25 |  | 414d |  |  | 4048h |
| 309 | 4.1.1 | **Creature Description Language (CDL)** |  | 132d | 2003-08-01 | 2004-02-02 |  | 414d |  |  | 1056h |
| 310 | 4.1.1.1 | Define Creature Description Language for interface to DE |  | 2mo | 2003-08-01 | 2003-10-01 |  | 414d | 0d | CMU-Clark | 352h |
| 311 | 4.1.1.2 | CDL Design review | milestone | 0mo | 2003-10-01 | 2003-10-01 | 310 | 392d | 0d |  |  |
| 312 | 4.1.1.3 | develop prototype DE interface with a basic toolset for eval |  | 1mo | 2003-10-02 | 2003-10-31 | 311 | 414d | 0d | CMU-Clark | 176h |
| 313 | 4.1.1.4 | Prototype CDL interface to DE plus sample toolset | milestone | 0mo | 2003-10-31 | 2003-10-31 | 312 | 392d | 0d |  |  |
| 314 | 4.1.1.5 | Refine toolset and DE interface; document |  | 3mo | 2003-11-03 | 2004-02-02 | 313 | 1151d | 0d | CMU-Clark | 528h |
| 315 | 4.1.1.6 | CDL v1.0 | milestone | 0mo | 2004-02-02 | 2004-02-02 | 314 | 1151d | 0d |  |  |

Notes:
- 286: The general philosophy will be to deploy sensors that are both easy to fabricate/install and likely to provide useful performance information (both for control and design evaluation) first, then move to more general purpose sensing modalities as the project progresses.
- 289: At M3, the goal is to have technologies identified and early bench-top prototypes of a foot pressure sensor (i.e. normal force) and in plane (lateral and for/aft) acceleration measurement.
- 293: At M6, these same initial sensors will be integrated onto the first run of hip/leg/foot prototypes and will include a local processor for / connection into the RiSE inter-robot communication system. / We (CMU and SU) will look into designing a relatively "standard" / foot/leg interface module (MCU plus ?? on PCB) for use during the / prototyping of sensing systems.
- 295: At M9, we will deploy sufficient sensing (either force at foot or strain in leg/ankle) to measure passive leg kinematics and/or ground reaction forces in addition to foot acceleration (for use in slip and touchdown detection).
- 297: For M12, we will explore strategies for including very low resolution proximity detection schemes on the feet to enhance foot touchdown prediction and detection.
- 301: Early Phase I in SOW
- 304: Collaboration among UCB, SU, CMU on low-level, distributed sensor processing or pre-processing to combat growing complexity and reduce the wiring problems between distal appendages and central processor. / Late Phase I
- 308: Jonathan Clark from Stanford will be representing Stanford's interest in this task which is mainly owned byBDI/CMU with some participation from UM.

| ID | WBS | Task | Type | Duration | Start | Finish | Predecessors | Total slack | Free slack | Resources | Work |
| --- | --- | --- | --- | --- | --- | --- | --- | --- | --- | --- | --- |
| 316 | 4.1.2 | **Parametrized Contact Mechanics (PCM) models** |  | 278.67d | 2003-08-01 | 2004-08-25 |  | 421.53d |  |  | 2200h |
| 317 | 4.1.2.1 | Purchase DE for project-wide use | milestone | 0mo | 2003-10-01 | 2003-10-01 | 2SS+2mo | 1261d |  |  |  |
| 318 | 4.1.2.2 | Needs Assessment for critical contact models |  | 1.67mo | 2003-08-01 | 2003-09-22 |  | 421.53d | 0d | SUGS-1(Jonathan) [80%]; UCBPD(Goldman) [50%] | 352h |
| 319 | 4.1.2.3 | Identification of initial PCM for development | milestone | 0mo | 2003-09-22 | 2003-09-22 | 318 | 421.53d | 0d |  |  |
| 320 | 4.1.2.4 | Design/select algorithm for initial prototype |  | 1.25mo | 2003-09-22 | 2003-10-30 | 319 | 421.53d | 0d | SUGS-1(Jonathan) [80%]; UCBPD(Goldman) [50%] | 264h |
| 321 | 4.1.2.5 | PCM Design Review | milestone | 0mo | 2003-10-30 | 2003-10-30 | 320 | 421.53d | 0d |  |  |
| 322 | 4.1.2.6 | Implement algorithms for most critical models |  | 1.25mo | 2003-10-30 | 2003-12-08 | 321 | 421.53d | 0d | SUGS-1(Jonathan) [80%]; UCBPD(Goldman) [50%] | 264h |
| 323 | 4.1.2.7 | PCM prototype v0.1 to be exercised by users | milestone | 0mo | 2003-12-08 | 2003-12-08 | 322 | 421.53d | 0d |  |  |
| 324 | 4.1.2.8 | Revise PCM and interface to DE as needed |  | 2.5mo | 2003-12-08 | 2004-02-23 | 323 | 1026.33d | 0d | SUGS-1(Jonathan) [80%]; UCBPD(Goldman) [50%] | 528h |
| 325 | 4.1.2.9 | Document PCMs and DE interface |  | 1.25mo | 2004-01-15 | 2004-02-23 | 324FF | 1026.33d | 0d | SUGS-1(Jonathan) [80%]; UCBPD(Goldman) [50%] | 264h |
| 326 | 4.1.2.10 | PCM v1.0 | milestone | 0mo | 2004-02-23 | 2004-02-23 | 325 | 1026.33d | 0d |  |  |
| 327 | 4.1.2.11 | Design, develop, integrate additional contact models |  | 6mo | 2004-02-23 | 2004-08-25 | 326 | 1026.33d |  | UCBPD(Goldman) [50%] | 528h |
| 328 | 4.1.3 | **Real-time Interface (RTI) of RiSELib to DE** |  | 198d | 2003-11-03 | 2004-08-04 |  | 1041d |  |  | 792h |
| 329 | 4.1.3.1 | Implement Real-time Interface (RTI) for RLB to DE |  | 1mo | 2003-11-03 | 2003-12-02 | 262 | 1041d | 0d | CMU-Uluc | 176h |
| 330 | 4.1.3.2 | RTI v0.1 interfaces RLB to DE | milestone | 0mo | 2003-12-02 | 2003-12-02 | 329 | 1041d | 0d |  |  |
| 331 | 4.1.3.3 | Modify RTI for migration of benchtop RLB to RiSE CPU and OS |  | 2mo | 2003-12-03 | 2004-02-02 | 330 | 1041d | 0d | CMU-Uluc | 352h |
| 332 | 4.1.3.4 | RTI v1.0 operational | milestone | 0mo | 2004-02-02 | 2004-02-02 | 331, 265 | 1041d | 0d |  |  |
| 333 | 4.1.3.5 | Evaluate and revise RTI |  | 6mo | 2004-02-03 | 2004-08-04 | 332 | 1041d | 0d | CMU-Uluc [25%] | 264h |
| 334 | 4.1.3.6 | RTI v2.0 | milestone | 0mo | 2004-08-04 | 2004-08-04 | 333 | 1041d |  |  |  |
| 335 | 4.1.4 | **Rendering Interface** |  | 22d | 2004-02-03 | 2004-03-03 |  | 1151d |  |  |  |
| 336 | 4.1.4.1 | Identify candidate interfaces |  | 1mo | 2004-02-03 | 2004-03-03 | 315 | 1151d |  |  |  |
| 337 | 4.2 | **Joint- and Limb-level Control** |  | 308d? | 2003-10-02 | 2004-12-06 |  | 418.78d |  |  | 6705.6h |
| 338 | 4.2.1 | **Limb Trajectory for Running** |  | 207.09d? | 2003-10-02 | 2004-07-19 |  | 418.78d |  |  | 3854.4h |
| 339 | 4.2.1.1 | Design Parametrized Trajectory Suite |  | 0.91mo | 2003-10-02 | 2003-10-30 | 222 | 418.78d | 0d | SUGS-2 (Daniel); Koditschek [10%]; UCBGS-1(Shai); CMU-Uluc [10%]; Cutkosky [10%] | 369.6h |
| 340 | 4.2.1.2 | Simulation Study of Trajectory Suite Flat Terrain |  | 0.96mo | 2003-11-03 | 2003-12-02 | 339, 313 | 416.87d | 0.96d | SUGS-2 (Daniel); Koditschek [10%]; UCBGS-1(Shai); CMU-Uluc [10%]; Cutkosky [10%] | 387.2h |
| 341 | 4.2.1.3 | Experimental Study of Trajectory Suite on Flat Terrain |  | 0.96mo | 2003-12-03 | 2004-01-01 | 226, 340 | 415.91d | 0d | SUGS-2 (Daniel); Koditschek [10%]; UCBGS-1(Shai); CMU-Uluc [10%]; Cutkosky [10%] | 387.2h |
| 342 | 4.2.1.4 | Simulation Study of Trajectory Suite on Rough Terrain |  | 0.96mo | 2004-01-01 | 2004-01-30 | 323, 341 | 415.91d | 0d | SUGS-2 (Daniel); Koditschek [10%]; UCBGS-1(Shai); CMU-Uluc [10%]; Cutkosky [10%] | 387.2h |
| 343 | 4.2.1.5 | Design Critique of Limb/Foot for Level Running | milestone | 0mo | 2004-01-30 | 2004-01-30 | 342 | 415.91d | 0d | SUGS-2 (Daniel); Koditschek [10%]; UCBGS-1(Shai); CMU-Uluc [10%]; Cutkosky [10%] |  |
| 344 | 4.2.1.6 | Integrate Sensory feedback into Running Controller and Explore 30o & 60o Slopes |  | 5.5mo? | 2004-01-30 | 2004-07-19 | 343 | 921.91d | 12.91d | SUGS-2 (Daniel); Koditschek [10%]; UCBGS-1(Shai); CMU-Uluc [10%]; Rizzi [10%]; Cutkosky [10%] | 2323.2h |

Notes:
- 323: One or two key contact models: one for the "challenge" vertical surface(e.g. stick/slip or compliant material / surface interaction); the other for a "rough" horizontal terrain
- 326: Feeds into task 4.2
- 331: RiSELib is revised to run on RiSE CPU rather than benchtop stack, so must adjust RTI accordingly
- 335: Begins after CDL complete at month 6
- 337: These tasks focus empirically on what it takes to get the limbs thown down to achieve traction and then what it takes to get them released with minimal impulse and/or drag. They start out using the crude mechanical test driver code inherited from the test procedures run by the mechanical designers and they evolve into finer position, velocity, force-controlled trajectories as empirical experience shows to be required.
- 338: Achieve RHex/Sprawl-like capabilities out of the evolving platform based upon initially near-open loop "push-up" style recirculating trajectory. Eventually add-in RHex-like coordination (feedforward/back; de/centralized) control and move onto 30o and 60o slopes. / [Kod, Rizzi, Haynes, Saranli]
- 339: Need to have general idea about kinematics and limb/foot morphology in order to start.

| ID | WBS | Task | Type | Duration | Start | Finish | Predecessors | Total slack | Free slack | Resources | Work |
| --- | --- | --- | --- | --- | --- | --- | --- | --- | --- | --- | --- |
| 345 | 4.2.2 | **Limb Trajectory for Climbing** |  | 58.38d | 2003-10-30 | 2004-01-20 |  | 421.53d |  |  | 492.8h |
| 346 | 4.2.2.1 | Design Parametrized Trajectory Suite |  | 0.7mo | 2003-10-30 | 2003-11-20 | 339 | 433.71d | 8.51d | BDI(EE1) [50%]; Koditschek [10%]; Buehler [10%]; SUGS-1(Jonathan) [20%]; Cutkosky [10%] | 123.2h |
| 347 | 4.2.2.2 | Experimental Study of Trajectory Suite on Soft Flat Vertical Terrain |  | 0.7mo | 2003-12-03 | 2003-12-24 | 226, 346, 340 | 425.2d | 3.67d | BDI(EE1) [50%]; Koditschek [10%]; Buehler [10%]; SUGS-1(Jonathan) [20%]; Cutkosky [10%] | 123.2h |
| 348 | 4.2.2.3 | Simulation Study of Trajectory Suite on Challenge Vertical Surface |  | 0.7mo | 2003-12-08 | 2003-12-30 | 323 | 421.53d | 0d | BDI(EE1) [50%]; Koditschek [10%]; Buehler [10%]; SUGS-1(Jonathan) [20%]; Cutkosky [10%] | 123.2h |
| 349 | 4.2.2.4 | Experimental Study of Trajectory Suite on Challenge Vertical Surface |  | 0.7mo | 2003-12-30 | 2004-01-20 | 348, 347 | 421.53d | 0d | BDI(EE1) [50%]; Koditschek [10%]; Buehler [10%]; SUGS-1(Jonathan) [20%]; Cutkosky [10%] | 123.2h |
| 350 | 4.2.2.5 | Design Critique of Limb/Foot for Vertical Climbing | milestone | 0mo | 2004-01-20 | 2004-01-20 | 349 | 421.53d | 9.53d | BDI(EE1) [50%]; Koditschek [10%]; Buehler [10%]; SUGS-1(Jonathan) [20%]; Cutkosky [10%] |  |
| 351 | 4.2.3 | **Sensor-based Trajectory Adjustment** |  | 132d | 2004-02-03 | 2004-08-04 |  | 412d |  |  | 2358.4h |
| 352 | 4.2.3.1 | Experimental studies of full robot failure modes on vertical (no dry adhesive) |  | 0.09mo | 2004-02-03 | 2004-02-04 | 350, 293 | 412d | 0d | Rizzi [10%]; Koditschek [10%]; CMU-Clark; SUGS-1(Jonathan) | 35.2h |
| 353 | 4.2.3.2 | Develo local contact fault detection strategies |  | 1mo | 2004-02-05 | 2004-03-05 | 352 | 412d | 0d | Rizzi [10%]; Koditschek [10%]; CMU-Clark; SUGS-1(Jonathan) | 387.2h |
| 354 | 4.2.3.3 | Test local fault detection, develop fault recovery/avoidance |  | 1mo | 2004-03-08 | 2004-04-06 | 353 | 412d | 0d | Rizzi [10%]; Koditschek [10%]; CMU-Clark; SUGS-1(Jonathan) | 387.2h |
| 355 | 4.2.3.4 | Slip Recovery Algorithm v0.1 | milestone | 0mo | 2004-04-06 | 2004-04-06 | 354 | 412d | 20d | Rizzi [10%]; Koditschek [10%]; CMU-Clark; SUGS-1(Jonathan) |  |
| 356 | 4.2.3.5 | Extend Fault Detecion and develop fault recovery/avoidance |  | 1mo | 2004-05-05 | 2004-06-03 | 355, 232 | 909d | 0d | Rizzi [10%]; Koditschek [10%]; CMU-Clark; SUGS-1(Jonathan) | 387.2h |
| 357 | 4.2.3.6 | Simulation studies of IMU/GRF sensory experiences on vertical |  | 1mo | 2004-05-05 | 2004-06-03 | 295, 280, 355 | 909d | 0d | Rizzi [10%]; Koditschek [10%]; CMU-Clark; SUGS-1(Jonathan) | 387.2h |
| 358 | 4.2.3.7 | Design IMU/GRF Feedback Policy for Improved Vertical Climbing |  | 1mo | 2004-06-04 | 2004-07-05 | 357, 356 | 909d | 0d | Rizzi [10%]; Koditschek [10%]; CMU-Clark; SUGS-1(Jonathan) | 387.2h |
| 359 | 4.2.3.8 | Test & Refine IMU/GRF Feedback Based Climbing |  | 1mo | 2004-07-06 | 2004-08-04 | 373FF, 358, 344FF | 909d | 0d | Rizzi [10%]; Koditschek [10%]; CMU-Clark; SUGS-1(Jonathan) | 387.2h |
| 360 | 4.2.3.9 | PostureAdjustmentAlgorithm v0.1 & SlipRecovery Algorithm v0.5 | milestone | 0mo | 2004-08-04 | 2004-08-04 | 359 | 909d | 0d | Rizzi [10%]; Koditschek [10%]; CMU-Clark; SUGS-1(Jonathan) |  |
| 361 | 4.2.4 | **Analysis and Refinement** |  | 88d | 2004-08-05 | 2004-12-06 |  | 909d |  |  |  |
| 362 | 4.2.4.1 | Integrate Running, Climbing Algorithms for Performance on Varied Slopes |  | 4mo | 2004-08-05 | 2004-12-06 | 360 | 909d | 0d |  |  |
| 363 | 4.2.4.2 | Demo Version of Climbing&Running Behaviors | milestone | 0mo | 2004-12-06 | 2004-12-06 | 362 | 909d | 0d |  |  |
| 364 | 4.3 | **Body-level Control** |  | 377.14d | 2003-08-01 | 2005-01-11 |  | 927.86d |  |  | 2974.4h |
| 365 | 4.3.1 | **Bioinspired Climbing Template** |  | 157.14d | 2003-08-01 | 2004-03-09 |  | 927.86d |  |  | 880h |
| 366 | 4.3.1.1 | Measure Kinematics & COM of Climbing Animals |  | 2.14mo | 2003-08-01 | 2003-10-07 |  | 927.86d | 0d | UCBPD(Goldman) [50%]; Koditschek [10%]; Full [10%] | 264h |
| 367 | 4.3.1.2 | Analyze COM Data & Hypothesize Template |  | 2mo | 2003-10-07 | 2003-12-08 | 366 | 927.86d | 0d | UCBPD(Goldman) [50%]; Koditschek [10%]; Full [10%] | 246.4h |
| 368 | 4.3.1.3 | Repeat Measurements with Perturbations to test and refine Hypothesis |  | 3mo | 2003-12-08 | 2004-03-09 | 367 | 927.86d | 0d | UCBPD(Goldman) [50%]; Koditschek [10%]; Full [10%] | 369.6h |
| 369 | 4.3.1.4 | Dynamical Climbing Template | milestone | 0mo | 2004-03-09 | 2004-03-09 | 368 | 927.86d | 0d | UCBPD(Goldman) [50%]; Koditschek [10%]; Full [10%] |  |

Notes:
- 345: Examining families of in-pulling "wax-on/wax-off" trajectories in simulation as well as experimentally. Work both ends of the platform capabilities/needs. Capabilities: determine what aspects of normal force pre-loading, stance-phase in-pulling & counter-back-torquing can be achieved by the limb actuators driving the specified kinematics. Needs: determine what aspects of same list are crucial in deploying the sticky clawed feet with high likelihood of achieving traction. / [Kod, Buehler, Campbell, Cutkosky, SUGSRA(s)]
- 351: Initially focus on a Grip Recovery Reflex:/ What to do when a stance leg slips: how to know when it's slipping; how to attempt to counter the slip; how to give up and flail again. / [Buehler, Cutkosky, Kod, Full, Rizzi & select GSRAs]
- 358: Must refine and integrate foot-sensor based slip-recovery as well now that sticky foot is available.
- 359: Coordinate refinement of leg posture with bioinspired study of animal climbing posture principle
- 361: Almost everyone on the project will work on these"last minute" improvements and empirical tricks
- 364: This task focuses on the implementation of the templatex/anchors/posture principle both respecting level as well as vertical climbing.
- 365: Measure and model the animal's COM while climbiing in settings where adequate traction is available. Conduct systematic climbing perturbation experiments to validate dynamical model. / [Kod, Full, Revson, Goldman, Simon]

| ID | WBS | Task | Type | Duration | Start | Finish | Predecessors | Total slack | Free slack | Constraint | Resources | Work |
| --- | --- | --- | --- | --- | --- | --- | --- | --- | --- | --- | --- | --- |
| 370 | 4.3.2 | **Anchoring Studies** |  | 220d | 2004-03-09 | 2005-01-11 |  | 927.86d |  |  |  | 1232h |
| 371 | 4.3.2.1 | Kinematic Data (steady state & perturbed) Analysis |  | 1mo | 2004-03-09 | 2004-04-08 | 369 | 927.86d | 0d |  | UCBPD(Goldman) [50%]; Koditschek [10%]; Full [10%] | 123.2h |
| 372 | 4.3.2.2 | Mathematical Analysis of COM & Posture Models |  | 3mo | 2004-04-08 | 2004-07-09 | 371 | 927.86d | 0d |  | UCBPD(Goldman) [50%]; Koditschek [10%]; Full [10%] | 369.6h |
| 373 | 4.3.2.3 | Hypothesize Posture Principle | milestone | 0mo | 2004-07-09 | 2004-07-09 | 372 | 927.86d | 0d |  | UCBPD(Goldman) [50%]; Koditschek [10%]; Full [10%] |  |
| 374 | 4.3.2.4 | Attempt to Refute Posture Principle with more experiments |  | 6mo | 2004-07-09 | 2005-01-11 | 373 | 927.86d |  |  | UCBPD(Goldman) [50%]; Koditschek [10%]; Full [10%] | 739.2h |
| 375 | 4.3.3 | **Accommodation of Surface Variation** |  | 106.86d | 2004-07-09 | 2004-12-06 |  | 909d |  |  |  | 862.4h |
| 376 | 4.3.3.1 | Measure Kinematics & COM of Climbing Animals on Broken Surfaces |  | 3mo | 2004-07-09 | 2004-10-11 | 373 | 927.86d | 18.86d |  | UCBPD(Goldman) [50%]; Koditschek [10%]; Full [10%] | 369.6h |
| 377 | 4.3.3.2 | Empirical Robot Studies Using Proximity Detector |  | 3mo | 2004-08-05 | 2004-11-04 | 297, 376FF | 909d | 0d |  | UCBPD(Goldman) [50%]; Koditschek [10%]; Full [10%] | 369.6h |
| 378 | 4.3.3.3 | Test & Refine Surface Variation Controller |  | 1mo | 2004-11-05 | 2004-12-06 | 377 | 909d | 0d |  | UCBPD(Goldman) [50%]; Koditschek [10%]; Full [10%] | 123.2h |
| 379 | 4.3.3.4 | Surface Variation Controller | milestone | 0mo | 2004-12-06 | 2004-12-06 | 378 | 909d | 0d |  | UCBPD(Goldman) [50%]; Koditschek [10%]; Full [10%] |  |
| 380 | 4.4 | **Global placement and navigation** |  | 220d | 2004-02-03 | 2004-12-06 |  | 953d |  |  |  | 2640h |
| 381 | 4.4.1 | **Surface Identification and GaitAdaptation** |  | 66d | 2004-08-05 | 2004-11-04 |  | 953d |  |  |  | 422.4h |
| 382 | 4.4.1.1 | Sensory Pattern Classification Study of Simple Compound Wall |  | 1mo | 2004-08-05 | 2004-09-03 | 360 | 953d | 0d |  | UMPD(Hal) [50%]; Koditschek [10%] | 105.6h |
| 383 | 4.4.1.2 | Empirical Gait Tuning Study on Simple Compound Wall Components |  | 1mo | 2004-08-05 | 2004-09-03 | 360 | 953d | 0d |  | UMPD(Hal) [50%]; Koditschek [10%] | 105.6h |
| 384 | 4.4.1.3 | Gait Adaptation Algorithm Design |  | 1mo | 2004-09-06 | 2004-10-05 | 382, 383 | 953d | 0d |  | UMPD(Hal) [50%]; Koditschek [10%] | 105.6h |
| 385 | 4.4.1.4 | Gait Adaptation Algorithm Test on Simple Compound Wall |  | 1mo | 2004-10-06 | 2004-11-04 | 384 | 953d | 0d |  | UMPD(Hal); Koditschek [10%] | 105.6h |
| 386 | 4.4.1.5 | Gait Adaptation on simple Compund Wall | milestone | 0mo | 2004-11-04 | 2004-11-04 | 385 | 953d | 0d |  | UMPD(Hal); Koditschek [10%] |  |
| 387 | 4.4.2 | **Transitions** |  | 220d | 2004-02-03 | 2004-12-06 |  | 953d |  |  |  | 2217.6h |
| 388 | 4.4.2.1 | Develop & Test Beacons for Onboard Vision System |  | 2.5mo | 2004-02-03 | 2004-04-19 | 303 | 964d | 0d |  | CMU-Sarjoun; Rizzi [10%]; Koditschek [10%] | 528h |
| 389 | 4.4.2.2 | Write and refine beacon driven transition event detector |  | 1mo | 2004-04-20 | 2004-05-19 | 388 | 964d | 0d |  | CMU-Sarjoun; Rizzi [10%]; Koditschek [10%] | 211.2h |
| 390 | 4.4.2.3 | Develop Algorithms for Upward Vertical-to-Level Transition |  | 2mo | 2004-05-20 | 2004-07-20 | 355, 389 | 964d | 0d |  | CMU-Sarjoun; Rizzi [10%]; Koditschek [10%] | 422.4h |
| 391 | 4.4.2.4 | Test & Refine Upward Vertical-to-Level Transition |  | 1mo | 2004-07-21 | 2004-08-19 | 390 | 964d | 0d | start no earlier than 2003-10-01 | CMU-Sarjoun; Rizzi [10%]; Koditschek [10%] | 211.2h |
| 392 | 4.4.2.5 | Develop Algorithms for Downward Vertical-to-Level Transition |  | 2mo | 2004-08-20 | 2004-10-20 | 391 | 964d | 0d |  | CMU-Sarjoun; Rizzi [10%]; Koditschek [10%] | 422.4h |
| 393 | 4.4.2.6 | Test & Refine Downwared Vertical-to-Level Transition |  | 1mo | 2004-10-21 | 2004-11-19 | 392 | 964d | 11d |  | CMU-Sarjoun; Rizzi [10%]; Koditschek [10%] | 211.2h |
| 394 | 4.4.2.7 | Vision Driven Compound Wall Transition |  | 1mo | 2004-11-05 | 2004-12-06 | 386 | 953d | 0d |  | CMU-Sarjoun; Rizzi [10%]; Koditschek [10%] | 211.2h |
| 395 | 4.4.2.8 | Sensor & Operator Triggered Transitions | milestone | 0mo | 2004-12-06 | 2004-12-06 | 394, 393 | 953d |  |  | CMU-Sarjoun; Rizzi [10%]; Koditschek [10%] |  |

Notes:
- 370: Explore climbing limb trajectory library (4.2.2) for postures that anchor the climbing template. Compare to konwn approaches fo ranchoring the SLIP in level runner. Initially all in simulation, increasingly on the physical platform. / [Kod, Full, Rizzi, Haynes, Saranli, Komsuoglu]
- 380: This is mostly a placeholder for activity that will come on in a big way after month 18.
- 381: Use 2-dim coordination plane (feedforward/back & de/centralized axes) and sensory suite to get pattern classification driven reactions. / [Kod, Rizzi, Haynes, Lin ]
- 387: Longer term focus on more general gait transitions: / How to switch from cyclic push-ups (running) into cyclic pull-ins (climbing) while "rearing" (level to vertical transition) and/or "reaching" (vertical to level transition) and back. / This will induce us to exercise the onboard vision system toward the end of phase 1.

| ID | WBS | Task | Type | Duration | Start | Finish | Predecessors | Total slack | Free slack |
| --- | --- | --- | --- | --- | --- | --- | --- | --- | --- |
| 396 | 5 | **Milestones and Demonstrations** |  | 44d | 2004-12-07 | 2005-02-04 |  | 909d |  |
| 397 | 5.1 | **Prep for Demos** |  | 44d | 2004-12-07 | 2005-02-04 |  | 909d |  |
| 398 | 5.1.1 | Preparing for trip to San Antonio |  | 2mo | 2004-12-07 | 2005-02-04 | 363, 379 | 909d | 0d |
| 399 | 5.2 | **Performance on Level Terrain** |  | 0d | 2005-02-04 | 2005-02-04 |  | 909d |  |
| 400 | 5.2.1 | 2 bl/s on flat Solid Surface (Asphalt, Rock) | milestone | 0mo | 2005-02-04 | 2005-02-04 | 398 | 909d |  |
| 401 | 5.2.2 | 1 bl/s on uneven (10% bodyheight variations) | milestone | 0mo | 2005-02-04 | 2005-02-04 | 398 | 909d |  |
| 402 | 5.2.3 | 1 bl/s on flat Lose terrain (gravel, sand, rubble) | milestone | 0mo | 2005-02-04 | 2005-02-04 | 398 | 909d |  |
| 403 | 5.2.4 | 1 bl/sec on uneven loose terrain | milestone | 0mo | 2005-02-04 | 2005-02-04 | 398 | 909d |  |
| 404 | 5.3 | **Performance on Slopes** |  | 0d | 2005-02-04 | 2005-02-04 |  | 909d |  |
| 405 | 5.3.1 | 90o Climbing at 1 bl/s (bark & wallboard) | milestone | 0mo | 2005-02-04 | 2005-02-04 | 398 | 909d |  |
| 406 | 5.3.2 | 60o Running at 1 bl/s (concrete & wood) | milestone | 0mo | 2005-02-04 | 2005-02-04 | 398 | 909d |  |
| 407 | 5.3.3 | 30o Running at 1 bl/s (metal & glass) | milestone | 0mo | 2005-02-04 | 2005-02-04 | 398 | 909d |  |
| 408 | 5.4 | **Performance in Transitions** |  | 0d | 2005-02-04 | 2005-02-04 |  | 909d |  |
| 409 | 5.4.1 | Up-to-Level at 0.1 bl/s (operator triggered) | milestone | 0mo | 2005-02-04 | 2005-02-04 | 398 | 909d |  |
| 410 | 5.4.2 | Vertical Down-to-level at 0.1 bl/s (operator triggered) | milestone | 0mo | 2005-02-04 | 2005-02-04 | 398 | 909d |  |
| 411 | 5.4.3 | Compound Vertical Surface Transition (beacon triggered) | milestone | 0mo | 2005-02-04 | 2005-02-04 | 398 | 909d |  |
